# 2Template

Schedule from MS Project, 2016-01-06 to 2016-03-02, costs in $, A marks actual dates.

## Calendars

- Standard: Mon-Fri 08:00-12:00, 13:00-17:00; Sat-Sun off.

## Resources

| Resource | Group | Rate |
| --- | --- | --- |
| vice president | management | 36.06 |
| office manager | management | 21.63 |
| intern | office staff | 10 |
| administrative assistant | office staff | 20 |
| operations manager | management | 25 |

## Schedule

| ID | WBS | Task | Type | Duration | Start | Finish | Predecessors | Complete | Remaining | Baseline start | Baseline finish | Baseline duration | Total slack | Free slack | Resources | Work | Actual work | Cost | Baseline cost | Actual cost |
| --- | --- | --- | --- | --- | --- | --- | --- | --- | --- | --- | --- | --- | --- | --- | --- | --- | --- | --- | --- | --- |
| 1 | 1 | **Shareholders Meeting** |  | 40.62d | 2016-01-06 A | 2016-03-02 |  | 58% | 17.14d | 2008-01-02 | 2008-02-27 | 41d | 0d |  |  | 603h | 389.45h | 27,256.06 | 26,788.08 | 9,409.21 |
| 2 | 1.1 | **Plan meeting** |  | 23.5d | 2016-01-06 A | 2016-02-08 |  | 75% | 5.88d | 2008-01-02 | 2008-02-04 | 23.5d | 0d |  |  | 368h | 276h | 17,744.62 | 17,744.62 | 5,808.46 |
| 3 | 1.1.1 | **Preliminary planning** |  | 23.5d | 2016-01-06 A | 2016-02-08 |  | 75% | 5.88d | 2008-01-02 | 2008-02-04 | 23.5d | 0d |  |  | 368h | 276h | 17,744.62 | 17,744.62 | 5,808.46 |
| 4 | 1.1.1.1 | Schedule conference date |  | 2d | 2016-01-06 A | 2016-01-07 |  | 75% | 0.5d | 2008-01-02 | 2008-01-03 | 2d | 1.5d | 0d | vice president; office manager | 32h | 24h | 923.08 | 923.08 | 692.31 |
| 5 | 1.1.1.2 | Book conference center |  | 2d | 2016-01-08 A | 2016-01-11 | 4 | 75% | 0.5d | 2008-01-04 | 2008-01-07 | 2d | 15d | 0d | intern | 16h | 12h | 160 | 160 | 120 |
| 6 | 1.1.1.3 | Book keynote speaker |  | 4w | 2016-01-11 A | 2016-02-08 | 5FS-0.5d | 75% | 1w | 2008-01-07 | 2008-02-04 | 4w | 0d |  | office manager; administrative assistant | 320h | 240h | 16,661.54 | 16,661.54 | 4,996.15 |
| 7 | 1.1.1.4 | Preliminary planning complete | milestone | 0d | 2016-02-08 A | 2016-02-08 | 6 | 75% | 0d | 2008-02-04 | 2008-02-04 | 0d | 0d |  |  |  |  |  |  |  |
| 8 | 1.2 | **Notification letter** |  | 8.88d | 2016-02-08 A | 2016-02-19 | 3 | 44% | 5.01d | 2008-02-04 | 2008-02-15 | 9.5d | 8.25d |  |  | 87h | 48.95h | 2,180.96 | 2,087.69 | 1,338.92 |
| 9 | 1.2.1 | Order letter stock |  | 1h | 2016-02-08 A | 2016-02-08 |  | 95% | 0.05h | 2008-02-04 | 2008-02-04 | 1h | 1.5d | 0d | intern | 1h | 0.95h | 260 | 260 | 259.5 |
| 10 | 1.2.2 | Develop letter |  | 2d | 2016-02-08 A | 2016-02-10 | 9 | 75% | 0.5d | 2008-02-04 | 2008-02-06 | 2d | 2.25d | 0d | administrative assistant | 16h | 12h | 320 | 320 | 240 |
| 11 | 1.2.3 | Review letter |  | 3.25d | 2016-02-10 A | 2016-02-15 | 10 | 69% | 1d | 2008-02-06 | 2008-02-11 | 3d | 0.62d | 0d | office manager; operations manager | 52h | 36h | 1,212.5 | 1,119.23 | 839.42 |
| 12 | 1.2.4 | Approve letter |  | 1d | 2016-02-15 | 2016-02-16 | 11 |  |  | 2008-02-11 | 2008-02-12 | 1d | 0.62d | 0d | vice president | 8h |  | 288.46 | 288.46 |  |
| 13 | 1.2.5 | Print letter |  | 2.5d | 2016-02-16 | 2016-02-19 | 12 |  |  | 2008-02-12 | 2008-02-15 | 2.5d | 0.62d |  | intern [50%] | 10h |  | 100 | 100 |  |
| 14 | 1.2.6 | Send letter | milestone | 0d | 2016-02-19 | 2016-02-19 | 13 |  |  | 2008-02-15 | 2008-02-15 | 0d | 8.25d |  |  |  |  |  |  |  |
| 15 | 1.3 | **Meeting details** |  | 11d | 2016-02-15 A | 2016-03-01 | 3 | 43% | 6.25d | 2008-02-11 | 2008-02-26 | 11d | 1d |  |  | 148h | 64.5h | 7,330.48 | 6,955.77 | 2,261.83 |
| 16 | 1.3.1 | Plan food with caterer |  | 4.62d | 2016-02-15 A | 2016-02-22 | 11 | 57% | 2d | 2008-02-11 | 2008-02-15 | 3.5d | 6.75d | 0d | administrative assistant; office manager | 74h | 42h | 5,040.48 | 4,665.77 | 874.33 |
| 17 | 1.3.2 | Arrange committee meeting rooms |  | 0.5d | 2016-02-15 A | 2016-02-16 | 16SS | 75% | 0.12d | 2008-02-11 | 2008-02-12 | 0.5d | 1.12d | 0d | intern | 4h | 3h | 940 | 940 | 705 |
| 18 | 1.3.3 | Arrange necessary equipment |  | 1.5d | 2016-02-16 A | 2016-02-17 | 17 | 75% | 0.38d | 2008-02-12 | 2008-02-13 | 1.5d | 2.62d | 0d | intern | 12h | 9h | 770 | 770 | 577.5 |
| 19 | 1.3.4 | Create agenda |  | 3.5d | 2016-02-17 A | 2016-02-23 | 18 | 75% | 0.88d | 2008-02-13 | 2008-02-19 | 3.5d | 0d |  | intern [50%] | 14h | 10.5h | 140 | 140 | 105 |
| 20 | 1.3.5 | Print agenda |  | 5.5d | 2016-02-23 | 2016-03-01 | 19 |  |  | 2008-02-19 | 2008-02-26 | 5.5d | 0d |  | intern | 44h |  | 440 | 440 |  |
| 21 | 1.3.6 | Meeting Details Complete | milestone | 0d | 2016-03-01 | 2016-03-01 | 20 |  |  | 2008-02-26 | 2008-02-26 | 0d | 1.38d |  |  |  |  |  |  |  |
| 22 | 1.4 | Meeting occurs! |  | 1d | 2016-03-01 | 2016-03-02 | 2FS+2d, 16, 17, 18, 20 |  |  | 2008-02-27 | 2008-02-27 | 1d | 0d |  |  |  |  |  |  |  |

Notes:
- 22: A Must Finish On constraint should be set for the day of the meeting.
